# Spring Schedule-FSAE

Schedule from MS Project, 2003-01-07 to 2003-05-16, A marks actual dates.
FAMU-FSU COE

## Calendars

- Standard: Mon-Fri 08:00-12:00, 13:00-17:00; Sat-Sun off. Exceptions (off unless hours are given): 2003-01-26 08:00-12:00, 13:00-17:00, 2003-02-08 08:00-12:00, 13:00-17:00.

## Schedule

| ID | WBS | Task | Duration | Start | Finish | Complete | Baseline start | Baseline finish | Baseline duration | Total slack | Constraint |
| --- | --- | --- | --- | --- | --- | --- | --- | --- | --- | --- | --- |
| 2 | 1 | Order Catalogs | 1d | 2003-01-07 A | 2003-01-07 A | 100% | 2003-01-07 | 2003-01-07 | 1d |  | start no earlier than 2003-01-07 |
| 3 | 2 | Web-page | 47d | 2003-01-14 | 2003-03-17 |  | 2003-01-14 | 2003-03-17 | 47d | 9d |  |
| 4 | 3 | Order Composite Supplies | 1d | 2003-01-22 | 2003-01-22 |  | 2003-01-22 | 2003-01-22 | 1d | 40d | start no earlier than 2003-01-22 |
| 5 | 4 | Order Bearings | 1d | 2003-01-22 | 2003-01-22 |  | 2003-01-22 | 2003-01-22 | 1d | 40d | start no earlier than 2003-01-22 |
| 6 | 5 | Order Raw Metal for Uprights, A-arms, Rotors, Spindles, Roll-bars ,Rear Chassis Section, Mounts, and Wheel Hubs | 1d | 2003-01-22 | 2003-01-22 |  | 2003-01-22 | 2003-01-22 | 1d | 40d | start no earlier than 2003-01-22 |
| 7 | 6 | Design Jig to Fabricate A-arms | 7d | 2003-01-14 | 2003-01-22 |  | 2003-01-14 | 2003-01-22 | 7d | 40d |  |
| 8 | 7 | Send Roll-bars out to be Mandrel Bent | 4d? | 2003-02-03 | 2003-02-06 |  | 2003-02-03 | 2003-02-06 | 4d? | 28d | start no earlier than 2003-02-03 |
| 9 | 8 | Cut Tubing for the A-arms and Rear Chassis Section | 2d | 2003-02-19 | 2003-02-20 |  | 2003-01-26 | 2003-01-27 | 2d | 17d | start no earlier than 2003-02-19 |
| 10 | 9 | A-arm Welding and Construction | 2d | 2003-02-21 | 2003-02-24 |  | 2003-01-29 | 2003-01-30 | 2d | 15d | start no earlier than 2003-02-21 |
| 11 | 10 | Machine Inserts for A-arms | 1d | 2003-02-25 | 2003-02-25 |  | 2003-01-31 | 2003-01-31 | 1d | 14d | start no earlier than 2003-02-25 |
| 12 | 11 | Rear Chassis Section Welding and Construction | 4d | 2003-02-26 | 2003-03-03 |  | 2003-02-08 | 2003-02-12 | 4d | 10d | start no earlier than 2003-02-26 |
| 13 | 12 | Order Brake Calipers | 1d | 2003-02-17 | 2003-02-17 |  |  |  |  | 20d | start no earlier than 2003-02-17 |
| 14 | 13 | Fabricate Uprights | 8d | 2003-02-17 | 2003-02-26 |  |  |  |  | 13d | start no earlier than 2003-02-16 |
| 15 | 14 | Fabricate Mounts | 1d | 2003-03-03 | 2003-03-03 |  |  |  |  | 10d | start no earlier than 2003-03-03 |
| 16 | 15 | Fabricate Rotors | 1d | 2003-03-04 | 2003-03-04 |  |  |  |  | 9d | start no earlier than 2003-03-04 |
| 17 | 16 | Fabricate Spindles | 1d | 2003-03-05 | 2003-03-05 |  |  |  |  | 8d | start no earlier than 2003-03-05 |
| 18 | 17 | Fabricate Wheel Hubs | 1d | 2003-03-06 | 2003-03-06 |  |  |  |  | 7d | start no earlier than 2003-03-06 |
| 19 | 18 | Fabricate Front Chassis Section | 4d | 2003-03-07 | 2003-03-12 |  |  |  |  | 3d | start no earlier than 2003-03-07 |
| 20 | 19 | Assemble Chassis | 1d | 2003-03-13 | 2003-03-13 |  |  |  |  | 2d | start no earlier than 2003-03-13 |
| 21 | 20 | Further Exploration of Charleston's Party Life | 6d | 2003-03-07 | 2003-03-14 |  |  |  |  | 1d | start no earlier than 2003-03-07 |
| 22 | 21 | Finalize Report | 9d | 2003-03-17 | 2003-03-27 |  |  |  |  | 36d | start no earlier than 2003-03-16 |
| 23 | 22 | Open House | 1d | 2003-04-03 | 2003-04-03 |  |  |  |  | 31d | start no earlier than 2003-04-03 |
| 24 | 23 | Competition and Further Exploration of Canada's Nightlife | 4d | 2003-05-13 | 2003-05-16 |  |  |  |  | 0d | start no earlier than 2003-05-13 |
